# CMMI Improvement Planning Template

Schedule from MS Project, 2006-01-04 to 2007-03-19.
ML2 - Definition PA en parallele

## Calendars

- Standard: Mon-Fri 08:00-12:00, 13:00-17:00; Sat-Sun off.

## Resources

| Resource |
| --- |
| EPG Leader |
| Process Owner |
| Workshop Team 1 |
| Workshop Team 2 |
| Workshop Team 3 |
| Workshop Team 4 |
| Peer 3 |
| SEI appraiser |
| Sponsor |
| Interviewee |
| Trainee |
| Peer 2 |
| Peer 1 |
| EPGS |
| SCAMPI team |
| Quality auditor |

## Schedule

| ID | WBS | Task | Type | Duration | Start | Finish | Predecessors | Total slack | Free slack | Constraint | Deadline | Resources | Work |
| --- | --- | --- | --- | --- | --- | --- | --- | --- | --- | --- | --- | --- | --- |
| 1 | 1 | **CMMI Software Improvement Project (SIP)** |  | 314d | 2006-01-04 08:00 | 2007-03-19 17:00 |  | 0d |  |  |  |  | 3786h |
| 2 | 1-A | **Initial assessment** |  | 22.5d | 2006-01-04 08:00 | 2006-02-03 12:00 |  | 25d |  |  |  |  | 12h |
| 3 | 1-A-1 | Kick-off meeting |  | 1d | 2006-01-04 08:00 | 2006-01-04 17:00 |  | 22d | 2d |  |  | EPG Leader; Sponsor | 8h |
| 4 | 1-A-2 | Interviews | milestone | 0d | 2006-01-23 08:00 | 2006-01-23 08:00 | 3FS+10d | 23d | 3d | start no earlier than 2006-01-23 08:00 | 2006-02-22 17:00 | Interviewee |  |
| 5 | 1-A-3 | Findings consolidation |  | 1d | 2006-01-26 08:00 | 2006-01-26 17:00 | 4 | 20d | 5d | start no earlier than 2006-01-26 08:00 | 2006-02-23 17:00 |  |  |
| 6 | 1-A-4 | Findings restitution meeting |  | 0.5d | 2006-02-03 08:00 | 2006-02-03 12:00 | 5 | 274.5d | 0.5d | start no earlier than 2006-02-03 08:00 |  | EPG Leader; Sponsor; Interviewee | 4h |
| 7 | 1-B | **Improvement start-up (OPF/OPD)** |  | 15d | 2006-02-06 08:00 | 2006-02-24 17:00 |  | 273.5d |  |  |  |  | 104h |
| 8 | 1-B-1 | Improvement plan elaboration (OPF) |  | 4d | 2006-02-06 08:00 | 2006-02-09 17:00 | 6 | 274d | 0d | finish no earlier than 2006-02-09 17:00 |  | EPG Leader | 32h |
| 9 | 1-B-2 | Improvement catalog definition (OPD) |  | 1d | 2006-02-10 08:00 | 2006-02-10 17:00 | 8 | 274d | 0d |  |  | EPG Leader | 8h |
| 10 | 1-B-3 | Improvement appointment note approval | milestone | 0d | 2006-02-10 17:00 | 2006-02-10 17:00 | 9 | 282d | 8d |  |  |  |  |
| 11 | 1-B-4 | Improvement baseline definition (OPD) |  | 4d | 2006-02-13 08:00 | 2006-02-16 17:00 | 9 | 274d | 0d |  |  | EPG Leader | 32h |
| 12 | 1-B-5 | Improvement documents review |  | 0.5d | 2006-02-23 08:00 | 2006-02-23 12:00 | 10, 11FS+4d | 274d | 0.5d |  |  | EPG Leader; Process Owner [500%] | 24h |
| 13 | 1-B-6 | Improvement documents release | milestone | 1d | 2006-02-24 08:00 | 2006-02-24 17:00 | 12 | 273.5d | 0d | start no earlier than 2006-02-24 08:00 |  | EPG Leader | 8h |
| 14 | 1-C | **Improvement kick-off** |  | 0.5d | 2006-02-28 08:00 | 2006-02-28 12:00 |  | 272.5d |  |  |  |  | 208h |
| 15 | 1-C-1 | CMMI model training session |  | 0.5d | 2006-02-28 08:00 | 2006-02-28 12:00 | 13 | 272.5d |  | start no earlier than 2006-02-28 08:00 |  | EPG Leader; Process Owner [500%]; Workshop Team 1 [500%]; Workshop Team 2 [500%]; Workshop Team 3 [500%]; Workshop Team 4 [500%] | 104h |
| 16 | 1-C-2 | Improvement kick-off session |  | 0.5d | 2006-02-28 08:00 | 2006-02-28 12:00 |  | 272.5d |  | start no earlier than 2006-02-28 08:00 |  | EPG Leader; Process Owner [500%]; Workshop Team 1 [500%]; Workshop Team 2 [500%]; Workshop Team 3 [500%]; Workshop Team 4 [500%]; EPGS | 104h |
| 17 | 1-D | **Improvement progress management** |  | 81d | 2006-03-01 08:00 | 2006-06-21 17:00 |  | 1d |  |  |  |  | 216h |
| 18 | 1-D-1 | **EPG meetings** |  | 80.5d | 2006-03-01 08:00 | 2006-06-21 12:00 |  | 191.5d |  |  |  |  | 216h |
| 19 | 1-D-1-a | EPG meeting 1 |  | 0.5d | 2006-03-01 08:00 | 2006-03-01 12:00 |  | 202d |  | start no earlier than 2006-03-01 08:00 |  | EPG Leader; Process Owner [500%] | 24h |
| 20 | 1-D-1-b | EPG meeting 2 |  | 0.5d | 2006-03-15 08:00 | 2006-03-15 12:00 |  | 192d |  | start no earlier than 2006-03-15 08:00 |  | EPG Leader; Process Owner [500%] | 24h |
| 21 | 1-D-1-c | EPG meeting 3 |  | 0.5d | 2006-03-29 08:00 | 2006-03-29 12:00 |  | 182d |  | start no earlier than 2006-03-29 08:00 |  | EPG Leader; Process Owner [500%] | 24h |
| 22 | 1-D-1-d | EPG meeting 4 |  | 0.5d | 2006-04-12 08:00 | 2006-04-12 12:00 |  | 172d |  | start no earlier than 2006-04-12 08:00 |  | EPG Leader; Process Owner [500%] | 24h |
| 23 | 1-D-1-e | EPG meeting 5 |  | 0.5d | 2006-04-26 08:00 | 2006-04-26 12:00 |  | 162d |  | start no earlier than 2006-04-26 08:00 |  | EPG Leader; Process Owner [500%] | 24h |
| 24 | 1-D-1-f | EPG meeting 6 |  | 0.5d | 2006-05-10 08:00 | 2006-05-10 12:00 |  | 152d |  | start no earlier than 2006-05-10 08:00 |  | EPG Leader; Process Owner [500%] | 24h |
| 25 | 1-D-1-g | EPG meeting 7 |  | 0.5d | 2006-05-24 08:00 | 2006-05-24 12:00 |  | 142d |  | start no earlier than 2006-05-24 08:00 |  | EPG Leader; Process Owner [500%] | 24h |
| 26 | 1-D-1-h | EPG meeting 8 |  | 0.5d | 2006-06-07 08:00 | 2006-06-07 12:00 |  | 132d |  | start no earlier than 2006-06-07 08:00 |  | EPG Leader; Process Owner [500%] | 24h |
| 27 | 1-D-1-i | EPG meeting 9 |  | 0.5d | 2006-06-21 08:00 | 2006-06-21 12:00 |  | 122d |  | start no earlier than 2006-06-21 08:00 |  | EPG Leader; Process Owner [500%] | 24h |

Notes:
- 1: Improvement planning for a CMMI maturity level 2 and OPD/OPF process at level 3 (the CMMI level 2 process areas are therefore established as defined processes) / hypothesis : / short timing / 5 groups in parallel for a 4 months definition phase, then a 6 months deployment phase / EPGS committee for supervision
- 3: 1 full day for EPG Leader = mini-assessement scope + Project and people identification + interviews detailed planning / 2h for sponsor to validate CMMI objectives, organizational unit scope and project list / with ALL4TEC consultant (external cost) / sponsor time is not on SIP
- 4: Each interview duration is 2 hours within 3 to 5 people (average = 4 people full time) / with ALL4TEC consultant (external cost) / The interviewees time is not counted
- 5: one full day for ALL4TEC consultant (external cost)
- 6: half day with all interviewees + sponsor + EPG Leader + ALL4TEC consultant (external cost) / Nb interviewees = 20 / sponsor time is not on SIP / The interviewees time is not counted
- 8: SIP development plan + budget + planning + dashboard + list risk + open isues list elaboration as a initial version / PO + Workshop team members + Peers identification / EPG + EPGS committee definition / EPGL + ALL4TEC consultant (external cost)
- 9: LIst of all process deliverables (policy, guideline, template, training...) with assigned responsibility, progress status to be used as SIP workload estimates attributes / EPGL + ALL4TEC consultant (external cost)
- 11: with all SIP process deliverables and project data are identified, definition of the SIP baseline identification, archiving, update, diffusion, communication and release rules (GED + CR) / if necessary creation of the physical database / must include the five following levels : / a) process / b) life-cycle models / c) tailoring criteria / guidelines / d) measures repository / e) miscellaneous : lessons learned, tools user manuals, trainings, best practices... / EPGL + ALL4TEC consultant (external cost)
- 12: Review with all PO for internal agreement and committement / Approved by the EPGS for high level management review / 5 different groups / EPGL + PO + ALL4TEC consultant (external cost)
- 13: All SIP documents must be frozen in a first version before project kick-off / One day of rework after review by EPGL
- 15: all EPG members (EPGL + PO + workshop team) must be trained to CMMI model before the workshops start / internal training done by ALL4TEC consultant / people participation records must be archived / 5 different groups with one PO + 4 workshop team
- 16: all EPG members (EPGL + PO + workshop team) + EPGS must be aware of the SIP project objectives + schedules and activities / internal training done by EPGL / 5 different groups / 4 members in EPGS (branch sponsor + branch quality + divisions) : time on on SIP
- 19: EPGL + all PO (5 different groups) + ALL4TEC consultant (external cost)
- 20: EPGL + all PO (5 different groups) + ALL4TEC consultant (external cost)
- 21: EPGL + all PO (5 different groups) + ALL4TEC consultant (external cost)
- 22: EPGL + all PO (5 different groups) + ALL4TEC consultant (external cost)
- 23: EPGL + all PO (5 different groups) + ALL4TEC consultant (external cost)
- 24: EPGL + all PO (5 different groups) + ALL4TEC consultant (external cost)
- 25: EPGL + all PO (5 different groups) + ALL4TEC consultant (external cost)
- 26: EPGL + all PO (5 different groups) + ALL4TEC consultant (external cost)
- 27: EPGL + all PO (5 different groups) + ALL4TEC consultant (external cost)

| ID | WBS | Task | Type | Duration | Start | Finish | Predecessors | Total slack | Free slack | Constraint | Resources | Work |
| --- | --- | --- | --- | --- | --- | --- | --- | --- | --- | --- | --- | --- |
| 28 | 1-D-2 | **EPGS meetings** |  | 80d | 2006-03-01 17:00 | 2006-06-21 17:00 |  | 0d |  |  |  |  |
| 29 | 1-D-2-a | EPGS meetings 1 | milestone | 0d | 2006-03-01 17:00 | 2006-03-01 17:00 |  | 0d |  | must finish on 2006-03-01 17:00 | EPG Leader; EPGS |  |
| 30 | 1-D-2-b | EPGS meetings 2 | milestone | 0d | 2006-03-15 17:00 | 2006-03-15 17:00 |  | 0d |  | must finish on 2006-03-15 17:00 | EPG Leader; EPGS |  |
| 31 | 1-D-2-c | EPGS meetings 3 | milestone | 0d | 2006-03-29 17:00 | 2006-03-29 17:00 |  | 0d |  | must finish on 2006-03-29 17:00 | EPG Leader; EPGS |  |
| 32 | 1-D-2-d | EPGS meetings 4 | milestone | 0d | 2006-04-12 17:00 | 2006-04-12 17:00 |  | 0d |  | must finish on 2006-04-12 17:00 | EPG Leader; EPGS |  |
| 33 | 1-D-2-e | EPGS meetings 5 | milestone | 0d | 2006-04-26 17:00 | 2006-04-26 17:00 |  | 0d |  | must finish on 2006-04-26 17:00 | EPG Leader; Sponsor; EPGS |  |
| 34 | 1-D-2-f | EPGS meetings 6 | milestone | 0d | 2006-05-10 17:00 | 2006-05-10 17:00 |  | 0d |  | must finish on 2006-05-10 17:00 | EPG Leader; Sponsor; EPGS |  |
| 35 | 1-D-2-g | EPGS meetings 7 | milestone | 0d | 2006-05-24 17:00 | 2006-05-24 17:00 |  | 0d |  | must finish on 2006-05-24 17:00 | EPG Leader; Sponsor; EPGS |  |
| 36 | 1-D-2-h | EPGS meetings 8 | milestone | 0d | 2006-06-07 17:00 | 2006-06-07 17:00 |  | 0d |  | must finish on 2006-06-07 17:00 | EPG Leader; Sponsor; EPGS |  |
| 37 | 1-D-2-i | EPGS meetings 9 | milestone | 0d | 2006-06-21 17:00 | 2006-06-21 17:00 |  | 0d |  | must finish on 2006-06-21 17:00 | EPG Leader; Sponsor; EPGS |  |
| 38 | 1-E | **Process ML2 definition** |  | 84.75d | 2006-03-08 08:00 | 2006-07-04 15:00 |  | 184.25d |  |  |  | 1934h |
| 39 | 1-E-1 | **REQM process definition** |  | 72d | 2006-03-08 08:00 | 2006-06-15 17:00 |  | 160d | 10.5d |  |  | 360h |
| 40 | 1-E-1-a | **REQM policy workshop** |  | 26d | 2006-03-08 08:00 | 2006-04-12 17:00 |  | 184d | 2d |  |  | 144h |
| 41 | 1-E-1-a-1 | REQM policy workshop 1 |  | 1d | 2006-03-08 08:00 | 2006-03-08 17:00 |  | 139.5d |  | start no earlier than 2006-03-08 08:00 | Process Owner [50%]; Workshop Team 1; Workshop Team 2 [50%]; Workshop Team 3 [50%]; Workshop Team 4 [50%] | 24h |
| 42 | 1-E-1-a-2 | REQM policy workshop 2 |  | 1d | 2006-03-15 08:00 | 2006-03-15 17:00 |  | 134.5d |  | start no earlier than 2006-03-15 08:00 | Process Owner [50%]; Workshop Team 1; Workshop Team 2 [50%]; Workshop Team 3 [50%]; Workshop Team 4 [50%] | 24h |
| 43 | 1-E-1-a-3 | REQM policy workshop 3 |  | 1d | 2006-03-22 08:00 | 2006-03-22 17:00 |  | 129.5d |  | start no earlier than 2006-03-22 08:00 | Process Owner [50%]; Workshop Team 1; Workshop Team 2 [50%]; Workshop Team 3 [50%]; Workshop Team 4 [50%] | 24h |
| 44 | 1-E-1-a-4 | REQM policy workshop 4 |  | 1d | 2006-03-29 08:00 | 2006-03-29 17:00 |  | 124.5d |  | start no earlier than 2006-03-29 08:00 | Process Owner [50%]; Workshop Team 1; Workshop Team 2 [50%]; Workshop Team 3 [50%]; Workshop Team 4 [50%] | 24h |
| 45 | 1-E-1-a-5 | REQM policy workshop 5 |  | 1d | 2006-04-05 08:00 | 2006-04-05 17:00 |  | 119.5d |  | start no earlier than 2006-04-05 08:00 | Process Owner [50%]; Workshop Team 1; Workshop Team 2 [50%]; Workshop Team 3 [50%]; Workshop Team 4 [50%] | 24h |
| 46 | 1-E-1-a-6 | REQM policy workshop 6 |  | 1d | 2006-04-12 08:00 | 2006-04-12 17:00 |  | 114.5d |  | start no earlier than 2006-04-12 08:00 | Process Owner [50%]; Workshop Team 1; Workshop Team 2 [50%]; Workshop Team 3 [50%]; Workshop Team 4 [50%] | 24h |
| 47 | 1-E-1-b | REQM policy review |  | 0.5d | 2006-04-26 08:00 | 2006-04-26 12:00 | 40FS+7d | 112.5d | 0.5d | start no earlier than 2006-04-26 08:00 | EPG Leader; Process Owner; Workshop Team 1; Peer 1; Peer 2; Peer 3 | 24h |
| 48 | 1-E-1-c | REQM policy release | milestone | 2d | 2006-04-27 08:00 | 2006-04-28 17:00 | 47 | 124.5d |  | start no earlier than 2006-04-27 08:00 | Workshop Team 1 | 16h |
| 49 | 1-E-1-d | **REQM guidelines workshop** |  | 16d | 2006-05-03 08:00 | 2006-05-24 17:00 |  | 162.5d | 2d |  |  | 96h |
| 50 | 1-E-1-d-1 | REQM guidelines workshop 1 |  | 1d | 2006-05-03 08:00 | 2006-05-03 17:00 | 47 | 108d |  | start no earlier than 2006-05-03 08:00 | Process Owner [50%]; Workshop Team 1; Workshop Team 2 [50%]; Workshop Team 3 [50%]; Workshop Team 4 [50%] | 24h |
| 51 | 1-E-1-d-2 | REQM guidelines workshop 2 |  | 1d | 2006-05-10 08:00 | 2006-05-10 17:00 |  | 103d |  | start no earlier than 2006-05-10 08:00 | Process Owner [50%]; Workshop Team 1; Workshop Team 2 [50%]; Workshop Team 3 [50%]; Workshop Team 4 [50%] | 24h |
| 52 | 1-E-1-d-3 | REQM guidelines workshop 3 |  | 1d | 2006-05-17 08:00 | 2006-05-17 17:00 |  | 98d |  | start no earlier than 2006-05-17 08:00 | Process Owner [50%]; Workshop Team 1; Workshop Team 2 [50%]; Workshop Team 3 [50%]; Workshop Team 4 [50%] | 24h |
| 53 | 1-E-1-d-4 | REQM guidelines workshop 4 |  | 1d | 2006-05-24 08:00 | 2006-05-24 17:00 |  | 93d |  | start no earlier than 2006-05-24 08:00 | Process Owner [50%]; Workshop Team 1; Workshop Team 2 [50%]; Workshop Team 3 [50%]; Workshop Team 4 [50%] | 24h |
| 54 | 1-E-1-e | REQM guidelines review |  | 0.5d | 2006-06-07 08:00 | 2006-06-07 12:00 | 49FS+7d | 91d | 0d | start no earlier than 2006-06-07 08:00 | EPG Leader; Process Owner; Workshop Team 1; Peer 1; Peer 2; Peer 3 | 24h |
| 55 | 1-E-1-f | REQM guidelines release | milestone | 2d | 2006-06-07 13:00 | 2006-06-09 12:00 | 54 | 91d | 0.5d |  | Workshop Team 1 | 16h |
| 56 | 1-E-1-g | REQM training elaboration |  | 3d | 2006-06-12 08:00 | 2006-06-14 17:00 | 55 | 90.5d | 0d | start no earlier than 2006-06-12 08:00 | Process Owner | 24h |
| 57 | 1-E-1-h | REQM training release | milestone | 1d | 2006-06-15 08:00 | 2006-06-15 17:00 | 56 | 90.5d |  |  | EPG Leader; Process Owner | 16h |

Notes:
- 29: EPGS meeting will be scheduled after each EPG meeting / EPGL + EPGS members (4) + ALL4TEC consultant (external cost) / EPGL time is already planned in EPG meetings task / EPGS time is not on SIP
- 30: EPGS meeting will be scheduled after each EPG meeting / EPGL + EPGS members (4) + ALL4TEC consultant (external cost) / EPGL time is already planned in EPG meetings task / EPGS time is not on SIP
- 31: EPGS meeting will be scheduled after each EPG meeting / EPGL + EPGS members (4) + ALL4TEC consultant (external cost) / EPGL time is already planned in EPG meetings task / EPGS time is not on SIP
- 32: EPGS meeting will be scheduled after each EPG meeting / EPGL + EPGS members (4) + ALL4TEC consultant (external cost) / EPGL time is already planned in EPG meetings task / EPGS time is not on SIP
- 33: EPGS meeting will be scheduled after each EPG meeting / EPGL + EPGS members (4) + ALL4TEC consultant (external cost) / EPGL time is already planned in EPG meetings task / EPGS time is not on SIP
- 34: EPGS meeting will be scheduled after each EPG meeting / EPGL + EPGS members (4) + ALL4TEC consultant (external cost) / EPGL time is already planned in EPG meetings task / EPGS time is not on SIP
- 35: EPGS meeting will be scheduled after each EPG meeting / EPGL + EPGS members (4) + ALL4TEC consultant (external cost) / EPGL time is already planned in EPG meetings task / EPGS time is not on SIP
- 36: EPGS meeting will be scheduled after each EPG meeting / EPGL + EPGS members (4) + ALL4TEC consultant (external cost) / EPGL time is already planned in EPG meetings task / EPGS time is not on SIP
- 37: EPGS meeting will be scheduled after each EPG meeting / EPGL + EPGS members (4) + ALL4TEC consultant (external cost) / EPGL time is already planned in EPG meetings task / EPGS time is not on SIP
- 41: Workshop to define the policy (every week on morning) / PO as leader / one workshop member is also the author and has full day time
- 42: Workshop to define the policy (every week on morning) / PO as leader / one workshop member is also the author and has full day time
- 43: Workshop to define the policy (every week on morning) / PO as leader / one workshop member is also the author and has full day time
- 44: Workshop to define the policy (every week on morning) / PO as leader / one workshop member is also the author and has full day time
- 45: Workshop to define the policy (every week on morning) / PO as leader / one workshop member is also the author and has full day time
- 46: Workshop to define the policy (every week on morning) / PO as leader / one workshop member is also the author and has full day time
- 47: Policy review with PO + author + EPGL + peers + ALL4TEC consultant (external cost)
- 48: 2 days of rework after review by author
- 50: Workshop to define the guides or templates (every week on morning) / PO as leader / one workshop member is also the author and has full day time
- 51: Workshop to define the guides or templates (every week on morning) / PO as leader / one workshop member is also the author and has full day time
- 52: Workshop to define the guides or templates (every week on morning) / PO as leader / one workshop member is also the author and has full day time
- 53: Workshop to define the guides or templates (every week on morning) / PO as leader / one workshop member is also the author and has full day time
- 54: Policy review with PO + author + EPGL + peers + ALL4TEC consultant (external cost)
- 55: 2 days of rework after review by author
- 56: 3 days for PO to elaborate a 2/3 h training materials (policy presentation + guidelines / templates overview)
- 57: review and imemdiate rework with PO + EPGL

| ID | WBS | Task | Type | Duration | Start | Finish | Predecessors | Total slack | Free slack | Constraint | Resources | Work |
| --- | --- | --- | --- | --- | --- | --- | --- | --- | --- | --- | --- | --- |
| 58 | 1-E-2 | **PP / PMC process definition** |  | 72d | 2006-03-08 08:00 | 2006-06-15 17:00 |  | 160d | 10.5d |  |  | 360h |
| 59 | 1-E-2-a | **PP / PMC policy workshop** |  | 26d | 2006-03-08 08:00 | 2006-04-12 17:00 |  | 184d | 2d |  |  | 144h |
| 60 | 1-E-2-a-1 | PP / PMC policy workshop 1 |  | 1d | 2006-03-08 08:00 | 2006-03-08 17:00 |  | 139.5d |  | start no earlier than 2006-03-08 08:00 | Process Owner [50%]; Workshop Team 1; Workshop Team 2 [50%]; Workshop Team 3 [50%]; Workshop Team 4 [50%] | 24h |
| 61 | 1-E-2-a-2 | PP / PMC policy workshop 2 |  | 1d | 2006-03-15 08:00 | 2006-03-15 17:00 |  | 134.5d |  | start no earlier than 2006-03-15 08:00 | Process Owner [50%]; Workshop Team 1; Workshop Team 2 [50%]; Workshop Team 3 [50%]; Workshop Team 4 [50%] | 24h |
| 62 | 1-E-2-a-3 | PP / PMC policy workshop 3 |  | 1d | 2006-03-22 08:00 | 2006-03-22 17:00 |  | 129.5d |  | start no earlier than 2006-03-22 08:00 | Process Owner [50%]; Workshop Team 1; Workshop Team 2 [50%]; Workshop Team 3 [50%]; Workshop Team 4 [50%] | 24h |
| 63 | 1-E-2-a-4 | PP / PMC policy workshop 4 |  | 1d | 2006-03-29 08:00 | 2006-03-29 17:00 |  | 124.5d |  | start no earlier than 2006-03-29 08:00 | Process Owner [50%]; Workshop Team 1; Workshop Team 2 [50%]; Workshop Team 3 [50%]; Workshop Team 4 [50%] | 24h |
| 64 | 1-E-2-a-5 | PP / PMC policy workshop 5 |  | 1d | 2006-04-05 08:00 | 2006-04-05 17:00 |  | 119.5d |  | start no earlier than 2006-04-05 08:00 | Process Owner [50%]; Workshop Team 1; Workshop Team 2 [50%]; Workshop Team 3 [50%]; Workshop Team 4 [50%] | 24h |
| 65 | 1-E-2-a-6 | PP / PMC policy workshop 6 |  | 1d | 2006-04-12 08:00 | 2006-04-12 17:00 |  | 114.5d |  | start no earlier than 2006-04-12 08:00 | Process Owner [50%]; Workshop Team 1; Workshop Team 2 [50%]; Workshop Team 3 [50%]; Workshop Team 4 [50%] | 24h |
| 66 | 1-E-2-b | PP / PMC policy review |  | 0.5d | 2006-04-26 08:00 | 2006-04-26 12:00 | 59FS+7d | 112.5d | 0.5d | start no earlier than 2006-04-26 08:00 | EPG Leader; Process Owner; Workshop Team 1; Peer 1; Peer 2; Peer 3 | 24h |
| 67 | 1-E-2-c | PP / PMC policy release | milestone | 2d | 2006-04-27 08:00 | 2006-04-28 17:00 | 66 | 124.5d |  | start no earlier than 2006-04-27 08:00 | Workshop Team 1 | 16h |
| 68 | 1-E-2-d | **PP / PMC guidelines workshop** |  | 16d | 2006-05-03 08:00 | 2006-05-24 17:00 |  | 162.5d | 2d |  |  | 96h |
| 69 | 1-E-2-d-1 | PP / PMC guidelines workshop 1 |  | 1d | 2006-05-03 08:00 | 2006-05-03 17:00 | 66 | 108d |  | start no earlier than 2006-05-03 08:00 | Process Owner [50%]; Workshop Team 1; Workshop Team 2 [50%]; Workshop Team 3 [50%]; Workshop Team 4 [50%] | 24h |
| 70 | 1-E-2-d-2 | PP / PMC guidelines workshop 2 |  | 1d | 2006-05-10 08:00 | 2006-05-10 17:00 |  | 103d |  | start no earlier than 2006-05-10 08:00 | Process Owner [50%]; Workshop Team 1; Workshop Team 2 [50%]; Workshop Team 3 [50%]; Workshop Team 4 [50%] | 24h |
| 71 | 1-E-2-d-3 | PP / PMC guidelines workshop 3 |  | 1d | 2006-05-17 08:00 | 2006-05-17 17:00 |  | 98d |  | start no earlier than 2006-05-17 08:00 | Process Owner [50%]; Workshop Team 1; Workshop Team 2 [50%]; Workshop Team 3 [50%]; Workshop Team 4 [50%] | 24h |
| 72 | 1-E-2-d-4 | PP / PMC guidelines workshop 4 |  | 1d | 2006-05-24 08:00 | 2006-05-24 17:00 |  | 93d |  | start no earlier than 2006-05-24 08:00 | Process Owner [50%]; Workshop Team 1; Workshop Team 2 [50%]; Workshop Team 3 [50%]; Workshop Team 4 [50%] | 24h |
| 73 | 1-E-2-e | PP / PMC guidelines review |  | 0.5d | 2006-06-07 08:00 | 2006-06-07 12:00 | 68FS+7d | 91d | 0d | start no earlier than 2006-06-07 08:00 | EPG Leader; Process Owner; Workshop Team 1; Peer 1; Peer 2; Peer 3 | 24h |
| 74 | 1-E-2-f | PP / PMC guidelines release | milestone | 2d | 2006-06-07 13:00 | 2006-06-09 12:00 | 73 | 91d | 0.5d |  | Workshop Team 1 | 16h |
| 75 | 1-E-2-g | PP / PMC training elaboration |  | 3d | 2006-06-12 08:00 | 2006-06-14 17:00 | 74 | 90.5d | 0d | start no earlier than 2006-06-12 08:00 | Process Owner | 24h |
| 76 | 1-E-2-h | PP / PMC training release | milestone | 1d | 2006-06-15 08:00 | 2006-06-15 17:00 | 75 | 90.5d |  |  | EPG Leader; Process Owner | 16h |
| 77 | 1-E-3 | **SAM process definition** |  | 42.5d | 2006-05-03 08:00 | 2006-06-30 12:00 |  | 149.5d | 0d |  |  | 264h |
| 78 | 1-E-3-a | **SAM policy workshop** |  | 11d | 2006-05-03 08:00 | 2006-05-17 17:00 |  | 171.5d | 0d |  |  | 72h |
| 79 | 1-E-3-a-1 | SAM policy workshop 1 |  | 1d | 2006-05-03 08:00 | 2006-05-03 17:00 |  | 112d |  | start no earlier than 2006-05-03 08:00 | Process Owner [50%]; Workshop Team 1; Workshop Team 2 [50%]; Workshop Team 3 [50%]; Workshop Team 4 [50%] | 24h |
| 80 | 1-E-3-a-2 | SAM policy workshop 2 |  | 1d | 2006-05-10 08:00 | 2006-05-10 17:00 |  | 107d |  | start no earlier than 2006-05-10 08:00 | Process Owner [50%]; Workshop Team 1; Workshop Team 2 [50%]; Workshop Team 3 [50%]; Workshop Team 4 [50%] | 24h |
| 81 | 1-E-3-a-3 | SAM policy workshop 3 |  | 1d | 2006-05-17 08:00 | 2006-05-17 17:00 |  | 102d |  | start no earlier than 2006-05-17 08:00 | Process Owner [50%]; Workshop Team 1; Workshop Team 2 [50%]; Workshop Team 3 [50%]; Workshop Team 4 [50%] | 24h |
| 82 | 1-E-3-b | SAM policy review |  | 0.5d | 2006-05-29 08:00 | 2006-05-29 12:00 | 78FS+7d | 102d | 0d | start no earlier than 2006-04-26 08:00 | EPG Leader; Process Owner; Workshop Team 1; Peer 1; Peer 2; Peer 3 | 24h |
| 83 | 1-E-3-c | SAM policy release | milestone | 2d | 2006-05-29 13:00 | 2006-05-31 12:00 | 82 | 102d |  | start no earlier than 2006-04-27 08:00 | Workshop Team 1 | 16h |

Notes:
- 60: Workshop to define the policy (every week on morning) / PO as leader / one workshop member is also the author and has full day time
- 61: Workshop to define the policy (every week on morning) / PO as leader / one workshop member is also the author and has full day time
- 62: Workshop to define the policy (every week on morning) / PO as leader / one workshop member is also the author and has full day time
- 63: Workshop to define the policy (every week on morning) / PO as leader / one workshop member is also the author and has full day time
- 64: Workshop to define the policy (every week on morning) / PO as leader / one workshop member is also the author and has full day time
- 65: Workshop to define the policy (every week on morning) / PO as leader / one workshop member is also the author and has full day time
- 66: Policy review with PO + author + EPGL + peers + ALL4TEC consultant (external cost)
- 67: 2 days of rework after review by author
- 69: Workshop to define the guides or templates (every week on morning) / PO as leader / one workshop member is also the author and has full day time
- 70: Workshop to define the guides or templates (every week on morning) / PO as leader / one workshop member is also the author and has full day time
- 71: Workshop to define the guides or templates (every week on morning) / PO as leader / one workshop member is also the author and has full day time
- 72: Workshop to define the guides or templates (every week on morning) / PO as leader / one workshop member is also the author and has full day time
- 73: Policy review with PO + author + EPGL + peers + ALL4TEC consultant (external cost)
- 74: 2 days of rework after review by author
- 75: 3 days for PO to elaborate a 2/3 h training materials (policy presentation + guidelines / templates overview)
- 76: review and imemdiate rework with PO + EPGL
- 79: Workshop to define the policy (every week on morning) / PO as leader / one workshop member is also the author and has full day time
- 80: Workshop to define the policy (every week on morning) / PO as leader / one workshop member is also the author and has full day time
- 81: Workshop to define the policy (every week on morning) / PO as leader / one workshop member is also the author and has full day time
- 82: Policy review with PO + author + EPGL + peers + ALL4TEC consultant (external cost)
- 83: 2 days of rework after review by author

| ID | WBS | Task | Type | Duration | Start | Finish | Predecessors | Total slack | Free slack | Constraint | Resources | Work |
| --- | --- | --- | --- | --- | --- | --- | --- | --- | --- | --- | --- | --- |
| 84 | 1-E-3-d | **SAM guidelines workshop** |  | 11d | 2006-05-31 08:00 | 2006-06-14 17:00 |  | 149.5d | 0d |  |  | 72h |
| 85 | 1-E-3-d-1 | SAM guidelines workshop 1 |  | 1d | 2006-05-31 08:00 | 2006-05-31 17:00 |  | 90d |  | start no earlier than 2006-05-31 08:00 | Process Owner [50%]; Workshop Team 1; Workshop Team 2 [50%]; Workshop Team 3 [50%]; Workshop Team 4 [50%] | 24h |
| 86 | 1-E-3-d-2 | SAM guidelines workshop 2 |  | 1d | 2006-06-07 08:00 | 2006-06-07 17:00 |  | 85d |  | start no earlier than 2006-06-07 08:00 | Process Owner [50%]; Workshop Team 1; Workshop Team 2 [50%]; Workshop Team 3 [50%]; Workshop Team 4 [50%] | 24h |
| 87 | 1-E-3-d-3 | SAM guidelines workshop 3 |  | 1d | 2006-06-14 08:00 | 2006-06-14 17:00 |  | 80d |  | start no earlier than 2006-06-14 08:00 | Process Owner [50%]; Workshop Team 1; Workshop Team 2 [50%]; Workshop Team 3 [50%]; Workshop Team 4 [50%] | 24h |
| 88 | 1-E-3-e | SAM guidelines review |  | 0.5d | 2006-06-22 08:00 | 2006-06-22 12:00 | 84FS+5d | 80d | 0d | start no earlier than 2006-06-07 08:00 | EPG Leader; Process Owner; Workshop Team 1; Peer 1; Peer 2; Peer 3 | 24h |
| 89 | 1-E-3-f | SAM guidelines release | milestone | 2d | 2006-06-22 13:00 | 2006-06-26 12:00 | 88 | 80d | 0d |  | Workshop Team 1 | 16h |
| 90 | 1-E-3-g | SAM training elaboration |  | 3d | 2006-06-26 13:00 | 2006-06-29 12:00 | 89 | 80d | 0d | start no earlier than 2006-06-12 08:00 | Process Owner | 24h |
| 91 | 1-E-3-h | SAM training release | milestone | 1d | 2006-06-29 13:00 | 2006-06-30 12:00 | 90 | 80d |  |  | EPG Leader; Process Owner | 16h |
| 92 | 1-E-4 | **CM process definition** |  | 42.5d | 2006-05-03 08:00 | 2006-06-30 12:00 |  | 149.5d | 0d |  |  | 264h |
| 93 | 1-E-4-a | **CM policy workshop** |  | 11d | 2006-05-03 08:00 | 2006-05-17 17:00 |  | 161d | 0d |  |  | 72h |
| 94 | 1-E-4-a-1 | CM policy workshop 1 |  | 1d | 2006-05-03 08:00 | 2006-05-03 17:00 |  | 101.5d |  | start no earlier than 2006-05-03 08:00 | Process Owner [50%]; Workshop Team 1; Workshop Team 2 [50%]; Workshop Team 3 [50%]; Workshop Team 4 [50%] | 24h |
| 95 | 1-E-4-a-2 | CM policy workshop 2 |  | 1d | 2006-05-10 08:00 | 2006-05-10 17:00 |  | 96.5d |  | start no earlier than 2006-05-10 08:00 | Process Owner [50%]; Workshop Team 1; Workshop Team 2 [50%]; Workshop Team 3 [50%]; Workshop Team 4 [50%] | 24h |
| 96 | 1-E-4-a-3 | CM policy workshop 3 |  | 1d | 2006-05-17 08:00 | 2006-05-17 17:00 |  | 91.5d |  | start no earlier than 2006-05-17 08:00 | Process Owner [50%]; Workshop Team 1; Workshop Team 2 [50%]; Workshop Team 3 [50%]; Workshop Team 4 [50%] | 24h |
| 97 | 1-E-4-b | CM policy review |  | 0.5d | 2006-05-29 08:00 | 2006-05-29 12:00 | 93FS+7d | 91.5d | 0d | start no earlier than 2006-04-26 08:00 | EPG Leader; Process Owner; Workshop Team 1; Peer 1; Peer 2; Peer 3 | 24h |
| 98 | 1-E-4-c | CM policy release |  | 2d | 2006-05-29 13:00 | 2006-05-31 12:00 | 97 | 102d |  | start no earlier than 2006-04-27 08:00 | Workshop Team 1 | 16h |
| 99 | 1-E-4-d | **CM guidelines workshop** |  | 11d | 2006-05-31 08:00 | 2006-06-14 17:00 |  | 149.5d | 0d |  |  | 72h |
| 100 | 1-E-4-d-1 | CM guidelines workshop 1 |  | 1d | 2006-05-31 08:00 | 2006-05-31 17:00 | 97 | 90d |  | start no earlier than 2006-05-31 08:00 | Process Owner [50%]; Workshop Team 1; Workshop Team 2 [50%]; Workshop Team 3 [50%]; Workshop Team 4 [50%] | 24h |
| 101 | 1-E-4-d-2 | CM guidelines workshop 2 |  | 1d | 2006-06-07 08:00 | 2006-06-07 17:00 |  | 85d |  | start no earlier than 2006-06-07 08:00 | Process Owner [50%]; Workshop Team 1; Workshop Team 2 [50%]; Workshop Team 3 [50%]; Workshop Team 4 [50%] | 24h |
| 102 | 1-E-4-d-3 | CM guidelines workshop 3 |  | 1d | 2006-06-14 08:00 | 2006-06-14 17:00 |  | 80d |  | start no earlier than 2006-06-14 08:00 | Process Owner [50%]; Workshop Team 1; Workshop Team 2 [50%]; Workshop Team 3 [50%]; Workshop Team 4 [50%] | 24h |
| 103 | 1-E-4-e | CM guidelines review |  | 0.5d | 2006-06-22 08:00 | 2006-06-22 12:00 | 99FS+5d | 80d | 0d | start no earlier than 2006-06-07 08:00 | EPG Leader; Process Owner; Workshop Team 1; Peer 1; Peer 2; Peer 3 | 24h |
| 104 | 1-E-4-f | CM guidelines release |  | 2d | 2006-06-22 13:00 | 2006-06-26 12:00 | 103 | 80d | 0d |  | Workshop Team 1 | 16h |
| 105 | 1-E-4-g | CM training elaboration |  | 3d | 2006-06-26 13:00 | 2006-06-29 12:00 | 104 | 80d | 0d | start no earlier than 2006-06-12 08:00 | Process Owner | 24h |
| 106 | 1-E-4-h | CM training release |  | 1d | 2006-06-29 13:00 | 2006-06-30 12:00 | 105 | 80d |  |  | EPG Leader; Process Owner | 16h |
| 107 | 1-E-5 | **PPQA / MA process definition** |  | 42.5d | 2006-05-03 08:00 | 2006-06-30 12:00 |  | 149.5d | 0d |  |  | 264h |
| 108 | 1-E-5-a | **PPQA / MA policy workshop** |  | 11d | 2006-05-03 08:00 | 2006-05-17 17:00 |  | 161d | 0d |  |  | 72h |
| 109 | 1-E-5-a-1 | PPQA / MA policy workshop 1 |  | 1d | 2006-05-03 08:00 | 2006-05-03 17:00 |  | 101.5d |  | start no earlier than 2006-05-03 08:00 | Process Owner [50%]; Workshop Team 1; Workshop Team 2 [50%]; Workshop Team 3 [50%]; Workshop Team 4 [50%] | 24h |
| 110 | 1-E-5-a-2 | PPQA / MA policy workshop 2 |  | 1d | 2006-05-10 08:00 | 2006-05-10 17:00 |  | 96.5d |  | start no earlier than 2006-05-10 08:00 | Process Owner [50%]; Workshop Team 1; Workshop Team 2 [50%]; Workshop Team 3 [50%]; Workshop Team 4 [50%] | 24h |
| 111 | 1-E-5-a-3 | PPQA / MA policy workshop 3 |  | 1d | 2006-05-17 08:00 | 2006-05-17 17:00 |  | 91.5d |  | start no earlier than 2006-05-17 08:00 | Process Owner [50%]; Workshop Team 1; Workshop Team 2 [50%]; Workshop Team 3 [50%]; Workshop Team 4 [50%] | 24h |
| 112 | 1-E-5-b | PPQA / MA policy review |  | 0.5d | 2006-05-29 08:00 | 2006-05-29 12:00 | 108FS+7d | 91.5d | 0d | start no earlier than 2006-04-26 08:00 | EPG Leader; Process Owner; Workshop Team 1; Peer 1; Peer 2; Peer 3 | 24h |
| 113 | 1-E-5-c | PPQA / MA policy release | milestone | 2d | 2006-05-29 13:00 | 2006-05-31 12:00 | 112 | 102d |  | start no earlier than 2006-04-27 08:00 | Workshop Team 1 | 16h |

Notes:
- 85: Workshop to define the guides or templates (every week on morning) / PO as leader / one workshop member is also the author and has full day time
- 86: Workshop to define the guides or templates (every week on morning) / PO as leader / one workshop member is also the author and has full day time
- 87: Workshop to define the guides or templates (every week on morning) / PO as leader / one workshop member is also the author and has full day time
- 88: Policy review with PO + author + EPGL + peers + ALL4TEC consultant (external cost)
- 89: 2 days of rework after review by author
- 90: 3 days for PO to elaborate a 2/3 h training materials (policy presentation + guidelines / templates overview)
- 91: review and imemdiate rework with PO + EPGL
- 94: Workshop to define the policy (every week on morning) / PO as leader / one workshop member is also the author and has full day time
- 95: Workshop to define the policy (every week on morning) / PO as leader / one workshop member is also the author and has full day time
- 96: Workshop to define the policy (every week on morning) / PO as leader / one workshop member is also the author and has full day time
- 97: Policy review with PO + author + EPGL + peers + ALL4TEC consultant (external cost)
- 98: 2 days of rework after review by author
- 100: Workshop to define the guides or templates (every week on morning) / PO as leader / one workshop member is also the author and has full day time
- 101: Workshop to define the guides or templates (every week on morning) / PO as leader / one workshop member is also the author and has full day time
- 102: Workshop to define the guides or templates (every week on morning) / PO as leader / one workshop member is also the author and has full day time
- 103: Policy review with PO + author + EPGL + peers + ALL4TEC consultant (external cost)
- 104: 2 days of rework after review by author
- 105: 3 days for PO to elaborate a 2/3 h training materials (policy presentation + guidelines / templates overview)
- 106: review and imemdiate rework with PO + EPGL
- 109: Workshop to define the policy (every week on morning) / PO as leader / one workshop member is also the author and has full day time
- 110: Workshop to define the policy (every week on morning) / PO as leader / one workshop member is also the author and has full day time
- 111: Workshop to define the policy (every week on morning) / PO as leader / one workshop member is also the author and has full day time
- 112: Policy review with PO + author + EPGL + peers + ALL4TEC consultant (external cost)
- 113: 2 days of rework after review by author

| ID | WBS | Task | Type | Duration | Start | Finish | Predecessors | Total slack | Free slack | Constraint | Resources | Work |
| --- | --- | --- | --- | --- | --- | --- | --- | --- | --- | --- | --- | --- |
| 114 | 1-E-5-d | **PPQA / MA guidelines workshop** |  | 11d | 2006-05-31 08:00 | 2006-06-14 17:00 |  | 149.5d | 0d |  |  | 72h |
| 115 | 1-E-5-d-1 | PPQA / MA guidelines workshop 1 |  | 1d | 2006-05-31 08:00 | 2006-05-31 17:00 | 112 | 90d |  | start no earlier than 2006-05-31 08:00 | Process Owner [50%]; Workshop Team 1; Workshop Team 2 [50%]; Workshop Team 3 [50%]; Workshop Team 4 [50%] | 24h |
| 116 | 1-E-5-d-2 | PPQA / MA guidelines workshop 2 |  | 1d | 2006-06-07 08:00 | 2006-06-07 17:00 |  | 85d |  | start no earlier than 2006-06-07 08:00 | Process Owner [50%]; Workshop Team 1; Workshop Team 2 [50%]; Workshop Team 3 [50%]; Workshop Team 4 [50%] | 24h |
| 117 | 1-E-5-d-3 | PPQA / MA guidelines workshop 3 |  | 1d | 2006-06-14 08:00 | 2006-06-14 17:00 |  | 80d |  | start no earlier than 2006-06-14 08:00 | Process Owner [50%]; Workshop Team 1; Workshop Team 2 [50%]; Workshop Team 3 [50%]; Workshop Team 4 [50%] | 24h |
| 118 | 1-E-5-e | PPQA / MA guidelines review |  | 0.5d | 2006-06-22 08:00 | 2006-06-22 12:00 | 114FS+5d | 80d | 0d | start no earlier than 2006-06-07 08:00 | EPG Leader; Process Owner; Workshop Team 1; Peer 1; Peer 2; Peer 3 | 24h |
| 119 | 1-E-5-f | PPQA / MA guidelines release | milestone | 2d | 2006-06-22 13:00 | 2006-06-26 12:00 | 118 | 80d | 0d |  | Workshop Team 1 | 16h |
| 120 | 1-E-5-g | PPQA / MA training elaboration |  | 3d | 2006-06-26 13:00 | 2006-06-29 12:00 | 119 | 80d | 0d | start no earlier than 2006-06-12 08:00 | Process Owner | 24h |
| 121 | 1-E-5-h | PPQA / MA training release | milestone | 1d | 2006-06-29 13:00 | 2006-06-30 12:00 | 120 | 80d |  |  | EPG Leader; Process Owner | 16h |
| 122 | 1-E-6 | Process definition mini-assessment | milestone | 2d | 2006-06-30 13:00 | 2006-07-04 12:00 | 39, 58, 77, 92, 107 | 149.5d | 0d |  | EPG Leader; Process Owner [500%]; Quality auditor | 112h |
| 123 | 1-E-7 | **Trainings session** |  | 0.25d | 2006-07-04 13:00 | 2006-07-04 15:00 |  | 184.25d |  |  |  | 310h |
| 124 | 1-E-7-a | REQM training session |  | 2h | 2006-07-04 13:00 | 2006-07-04 15:00 | 122 | 184.25d |  |  | Process Owner; Trainee [3000%] | 62h |
| 125 | 1-E-7-b | PP / PMC training session |  | 2h | 2006-07-04 13:00 | 2006-07-04 15:00 | 122 | 184.25d |  |  | Process Owner; Trainee [3000%] | 62h |
| 126 | 1-E-7-c | SAM training session |  | 2h | 2006-07-04 13:00 | 2006-07-04 15:00 | 122 | 184.25d |  |  | Process Owner; Trainee [3000%] | 62h |
| 127 | 1-E-7-d | CM training session |  | 2h | 2006-07-04 13:00 | 2006-07-04 15:00 | 122 | 184.25d |  |  | Process Owner; Trainee [3000%] | 62h |
| 128 | 1-E-7-e | PPQA / MA training session |  | 2h | 2006-07-04 13:00 | 2006-07-04 15:00 | 122 | 184.25d |  |  | Process Owner; Trainee [3000%] | 62h |
| 129 | 1-F | **Process deployment on pilot projects** |  | 131d | 2006-07-05 17:00 | 2007-01-04 17:00 |  | 0d |  |  |  | 592h |
| 130 | 1-F-1 | **Project support** |  | 75.5d | 2006-09-06 08:00 | 2006-12-20 12:00 |  | 9.5d |  |  |  | 384h |
| 131 | 1-F-1-a | Project support 1 |  | 0.5d | 2006-09-06 08:00 | 2006-09-06 12:00 |  | 84.5d |  | start no earlier than 2006-09-06 08:00 | Process Owner [500%]; EPG Leader | 24h |
| 132 | 1-F-1-b | Project support 2 |  | 0.5d | 2006-09-13 08:00 | 2006-09-13 12:00 |  | 79.5d |  | start no earlier than 2006-09-13 08:00 | Process Owner [500%]; EPG Leader | 24h |
| 133 | 1-F-1-c | Project support 3 |  | 0.5d | 2006-09-20 08:00 | 2006-09-20 12:00 |  | 74.5d |  | start no earlier than 2006-09-20 08:00 | Process Owner [500%]; EPG Leader | 24h |
| 134 | 1-F-1-d | Project support 4 |  | 0.5d | 2006-09-27 08:00 | 2006-09-27 12:00 |  | 69.5d |  | start no earlier than 2006-09-27 08:00 | Process Owner [500%]; EPG Leader | 24h |
| 135 | 1-F-1-e | Project support 5 |  | 0.5d | 2006-10-04 08:00 | 2006-10-04 12:00 |  | 64.5d |  | start no earlier than 2006-10-04 08:00 | Process Owner [500%]; EPG Leader | 24h |
| 136 | 1-F-1-f | Project support 6 |  | 0.5d | 2006-10-11 08:00 | 2006-10-11 12:00 |  | 59.5d |  | start no earlier than 2006-10-11 08:00 | Process Owner [500%]; EPG Leader | 24h |
| 137 | 1-F-1-g | Project support 7 |  | 0.5d | 2006-10-18 08:00 | 2006-10-18 12:00 |  | 54.5d |  | start no earlier than 2006-10-18 08:00 | Process Owner [500%]; EPG Leader | 24h |
| 138 | 1-F-1-h | Project support 8 |  | 0.5d | 2006-10-25 08:00 | 2006-10-25 12:00 |  | 49.5d |  | start no earlier than 2006-10-25 08:00 | Process Owner [500%]; EPG Leader | 24h |
| 139 | 1-F-1-i | Project support 9 |  | 0.5d | 2006-11-01 08:00 | 2006-11-01 12:00 |  | 44.5d |  | start no earlier than 2006-11-01 08:00 | Process Owner [500%]; EPG Leader | 24h |
| 140 | 1-F-1-j | Project support 10 |  | 0.5d | 2006-11-08 08:00 | 2006-11-08 12:00 |  | 39.5d |  | start no earlier than 2006-11-08 08:00 | Process Owner [500%]; EPG Leader | 24h |
| 141 | 1-F-1-k | Project support 11 |  | 0.5d | 2006-11-15 08:00 | 2006-11-15 12:00 |  | 34.5d |  | start no earlier than 2006-11-15 08:00 | Process Owner [500%]; EPG Leader | 24h |
| 142 | 1-F-1-l | Project support 12 |  | 0.5d | 2006-11-22 08:00 | 2006-11-22 12:00 |  | 29.5d |  | start no earlier than 2006-11-22 08:00 | Process Owner [500%]; EPG Leader | 24h |
| 143 | 1-F-1-m | Project support 13 |  | 0.5d | 2006-11-29 08:00 | 2006-11-29 12:00 |  | 24.5d |  | start no earlier than 2006-11-29 08:00 | Process Owner [500%]; EPG Leader | 24h |
| 144 | 1-F-1-n | Project support 14 |  | 0.5d | 2006-12-06 08:00 | 2006-12-06 12:00 |  | 19.5d |  | start no earlier than 2006-12-06 08:00 | Process Owner [500%]; EPG Leader | 24h |
| 145 | 1-F-1-o | Project support 15 |  | 0.5d | 2006-12-13 08:00 | 2006-12-13 12:00 |  | 14.5d |  | start no earlier than 2006-12-13 08:00 | Process Owner [500%]; EPG Leader | 24h |
| 146 | 1-F-1-p | Project support 16 |  | 0.5d | 2006-12-20 08:00 | 2006-12-20 12:00 |  | 9.5d |  | start no earlier than 2006-12-20 08:00 | Process Owner [500%]; EPG Leader | 24h |

Notes:
- 115: Workshop to define the guides or templates (every week on morning) / PO as leader / one workshop member is also the author and has full day time
- 116: Workshop to define the guides or templates (every week on morning) / PO as leader / one workshop member is also the author and has full day time
- 117: Workshop to define the guides or templates (every week on morning) / PO as leader / one workshop member is also the author and has full day time
- 118: Policy review with PO + author + EPGL + peers + ALL4TEC consultant (external cost)
- 119: 2 days of rework after review by author
- 120: 3 days for PO to elaborate a 2/3 h training materials (policy presentation + guidelines / templates overview)
- 121: review and imemdiate rework with PO + EPGL
- 122: EPGL + all PO + ALL4TEC consultant (extenal consultant) / on the first complete and frozen SIP baseline : establish the CMMI practices traceability matrix
- 124: PO provides the training for all trainees (system + software people) on pilot projects / duration = 2h / nb trainees = 30 (to be confirmed)
- 125: PO provides the training for all trainees (system + software people) on pilot projects / duration = 2h / nb trainees = 30 (to be confirmed)
- 126: PO provides the training for all trainees (system + software people) on pilot projects / duration = 2h / nb trainees = 30 (to be confirmed)
- 127: PO provides the training for all trainees (system + software people) on pilot projects / duration = 2h / nb trainees = 30 (to be confirmed)
- 128: PO provides the training for all trainees (system + software people) on pilot projects / duration = 2h / nb trainees = 30 (to be confirmed)
- 131: 0,5 day per week for each PO to help the process deployment on project and establish the PII matrix / 0,5 day er week for EPGL to manage OPF/OPD
- 132: 0,5 day per week for each PO to help the process deployment on project and establish the PII matrix / 0,5 day er week for EPGL to manage OPF/OPD
- 133: 0,5 day per week for each PO to help the process deployment on project and establish the PII matrix / 0,5 day er week for EPGL to manage OPF/OPD
- 134: 0,5 day per week for each PO to help the process deployment on project and establish the PII matrix / 0,5 day er week for EPGL to manage OPF/OPD
- 135: 0,5 day per week for each PO to help the process deployment on project and establish the PII matrix / 0,5 day er week for EPGL to manage OPF/OPD
- 136: 0,5 day per week for each PO to help the process deployment on project and establish the PII matrix / 0,5 day er week for EPGL to manage OPF/OPD
- 137: 0,5 day per week for each PO to help the process deployment on project and establish the PII matrix / 0,5 day er week for EPGL to manage OPF/OPD
- 138: 0,5 day per week for each PO to help the process deployment on project and establish the PII matrix / 0,5 day er week for EPGL to manage OPF/OPD
- 139: 0,5 day per week for each PO to help the process deployment on project and establish the PII matrix / 0,5 day er week for EPGL to manage OPF/OPD
- 140: 0,5 day per week for each PO to help the process deployment on project and establish the PII matrix / 0,5 day er week for EPGL to manage OPF/OPD
- 141: 0,5 day per week for each PO to help the process deployment on project and establish the PII matrix / 0,5 day er week for EPGL to manage OPF/OPD
- 142: 0,5 day per week for each PO to help the process deployment on project and establish the PII matrix / 0,5 day er week for EPGL to manage OPF/OPD
- 143: 0,5 day per week for each PO to help the process deployment on project and establish the PII matrix / 0,5 day er week for EPGL to manage OPF/OPD
- 144: 0,5 day per week for each PO to help the process deployment on project and establish the PII matrix / 0,5 day er week for EPGL to manage OPF/OPD
- 145: 0,5 day per week for each PO to help the process deployment on project and establish the PII matrix / 0,5 day er week for EPGL to manage OPF/OPD
- 146: 0,5 day per week for each PO to help the process deployment on project and establish the PII matrix / 0,5 day er week for EPGL to manage OPF/OPD

| ID | WBS | Task | Type | Duration | Start | Finish | Predecessors | Total slack | Constraint | Resources | Work |
| --- | --- | --- | --- | --- | --- | --- | --- | --- | --- | --- | --- |
| 147 | 1-F-2 | **Process Change meetings** |  | 65.5d | 2006-09-06 08:00 | 2006-12-06 12:00 |  | 71.5d |  |  | 96h |
| 148 | 1-F-2-a | Process Change meetings 1 |  | 0.5d | 2006-09-06 08:00 | 2006-09-06 12:00 |  | 136.5d | start no earlier than 2006-09-06 08:00 | EPG Leader; Process Owner [500%] | 24h |
| 149 | 1-F-2-b | Process Change meetings 2 |  | 0.5d | 2006-10-04 08:00 | 2006-10-04 12:00 |  | 116.5d | start no earlier than 2006-10-04 08:00 | EPG Leader; Process Owner [500%] | 24h |
| 150 | 1-F-2-c | Process Change meetings 3 |  | 0.5d | 2006-11-01 08:00 | 2006-11-01 12:00 |  | 96.5d | start no earlier than 2006-11-01 08:00 | EPG Leader; Process Owner [500%] | 24h |
| 151 | 1-F-2-d | Process Change meetings 4 |  | 0.5d | 2006-12-06 08:00 | 2006-12-06 12:00 |  | 71.5d | start no earlier than 2006-12-06 08:00 | EPG Leader; Process Owner [500%] | 24h |
| 152 | 1-F-3 | **EPGS meetings** |  | 110d | 2006-07-05 17:00 | 2006-12-06 17:00 |  | 0d |  |  |  |
| 153 | 1-F-3-a | EPGS meetings 1 | milestone | 0d | 2006-07-05 17:00 | 2006-07-05 17:00 |  | 0d | must finish on 2006-07-05 17:00 | EPG Leader; Process Owner [500%]; EPGS |  |
| 154 | 1-F-3-b | EPGS meetings 2 | milestone | 0d | 2006-08-02 17:00 | 2006-08-02 17:00 |  | 0d | must finish on 2006-08-02 17:00 | EPG Leader; Process Owner [500%]; EPGS |  |
| 155 | 1-F-3-c | EPGS meetings 3 | milestone | 0d | 2006-09-06 17:00 | 2006-09-06 17:00 |  | 0d | must finish on 2006-09-06 17:00 | EPG Leader; Process Owner [500%]; EPGS |  |
| 156 | 1-F-3-d | EPGS meetings 4 | milestone | 0d | 2006-10-04 17:00 | 2006-10-04 17:00 |  | 0d | must finish on 2006-10-04 17:00 | EPG Leader; Process Owner [500%]; EPGS |  |
| 157 | 1-F-3-e | EPGS meetings 5 | milestone | 0d | 2006-11-01 17:00 | 2006-11-01 17:00 |  | 0d | must finish on 2006-11-01 17:00 | EPG Leader; Process Owner [500%]; EPGS |  |
| 158 | 1-F-3-f | EPGS meetings 6 | milestone | 0d | 2006-12-06 17:00 | 2006-12-06 17:00 |  | 0d | must finish on 2006-12-06 17:00 | EPG Leader; Process Owner [500%]; EPGS |  |
| 159 | 1-F-4 | Process deployment mini-assessment |  | 2d | 2007-01-03 08:00 | 2007-01-04 17:00 | 130 | 0d | start no earlier than 2007-01-03 08:00 | EPG Leader; Process Owner [500%]; Quality auditor | 112h |
| 160 | 1-G | **SCAMPI official appraisal** |  | 136d | 2006-09-11 08:00 | 2007-03-19 17:00 |  | 0d |  |  | 720h |
| 161 | 1-G-1 | SCAMPI team building |  | 3d | 2006-09-11 08:00 | 2006-09-13 17:00 | 122 | 101d | start no earlier than 2006-09-11 08:00 | SCAMPI team [600%]; SEI appraiser | 144h |
| 162 | 1-G-2 | SCAMPI Readiness |  | 3d | 2007-02-01 17:00 | 2007-02-06 17:00 | 161, 159FS+20d | 0d |  | SCAMPI team [600%]; SEI appraiser | 144h |
| 163 | 1-G-3 | SCAMPI on site |  | 9d | 2007-03-06 17:00 | 2007-03-19 17:00 | 162FS+20d | 0d |  | SEI appraiser; SCAMPI team [600%]; Interviewee | 432h |

Notes:
- 148: Each month, a Process change committee to analyze the deployment progress and possible process changes / with EPGL + all PO + ALL4TEC consultant (external cost)
- 149: Each month, a Process change committee to analyze the deployment progress and possible process changes / with EPGL + all PO + ALL4TEC consultant (external cost)
- 150: Each month, a Process change committee to analyze the deployment progress and possible process changes / with EPGL + all PO + ALL4TEC consultant (external cost)
- 151: Each month, a Process change committee to analyze the deployment progress and possible process changes / with EPGL + all PO + ALL4TEC consultant (external cost)
- 153: EPGS meeting will be scheduled after each Proces Change meeting / EPGL + EPGS members (4) + ALL4TEC consultant (external cost) / EPGL time is already planned in Process Change meetings task / EPGS time is not on SIP
- 154: EPGS meeting will be scheduled after each Proces Change meeting / EPGL + EPGS members (4) + ALL4TEC consultant (external cost) / EPGL time is already planned in Process Change meetings task / EPGS time is not on SIP
- 155: EPGS meeting will be scheduled after each Proces Change meeting / EPGL + EPGS members (4) + ALL4TEC consultant (external cost) / EPGL time is already planned in Process Change meetings task / EPGS time is not on SIP
- 156: EPGS meeting will be scheduled after each Proces Change meeting / EPGL + EPGS members (4) + ALL4TEC consultant (external cost) / EPGL time is already planned in Process Change meetings task / EPGS time is not on SIP
- 157: EPGS meeting will be scheduled after each Proces Change meeting / EPGL + EPGS members (4) + ALL4TEC consultant (external cost) / EPGL time is already planned in Process Change meetings task / EPGS time is not on SIP
- 158: EPGS meeting will be scheduled after each Proces Change meeting / EPGL + EPGS members (4) + ALL4TEC consultant (external cost) / EPGL time is already planned in Process Change meetings task / EPGS time is not on SIP
- 159: EPGL + all PO + ALL4TEC consultant (extenal consultant) / on the first complete and frozen SIP baseline : validate the project PII traceability matrix
- 161: all SCAMPI team members (trained previousely to SEI official CMMI introduction course) / SCAMPI team = 6 members (3 VEMS internal and 3 from other VALEO entities) / + SEI appraiser (external cost)
- 162: SCAMPI team members + SEI appraiser analyze the project PII matrix and establish a GO/NO GO decision for SCAMPI on site phase / SCAMPI team = 6 / SEI appraiser (external cost)
- 163: Each interview duration is 2 hours within 3 to 5 people (average = 4 people full time) / with SCAMPI team (6 members) / with SEI appraiser (external cost) / The interviewees time is not counted
